Schedule from MS Project MPX, 2020-06-16 to 2020-08-24.

## Calendars

- Standard: Mon-Sun 08:00 am-12:00 pm, 01:00 pm-05:00 pm.

## Schedule

| ID | WBS | Task | Duration | Start | Finish | Predecessors |
| --- | --- | --- | --- | --- | --- | --- |
| 1 | 1 | 2 Week Return Notic | 14d | 2020-06-16 | 2020-06-29 |  |
| 2 | 2 | 2 Week Restore Period | 14d | 2020-06-30 | 2020-07-13 | 1 |
| 3 | 3 | **Lock Ups** | 14d | 2020-06-30 | 2020-07-13 |  |
| 4 | 3.1 | CEBAF Open | 1d | 2020-06-30 | 2020-06-30 |  |
| 5 | 3.2 | INJ Locked Up | 13d | 2020-07-01 | 2020-07-13 |  |
| 6 | 3.3 | NL Locked Up | 12d | 2020-07-02 | 2020-07-13 |  |
| 7 | 3.4 | SL/BSY Lock Up | 11d | 2020-07-03 | 2020-07-13 |  |
| 8 | 3.5 | Hall A Lock Up | 1d | 2020-07-08 | 2020-07-08 |  |
| 9 | 3.6 | Hall B Lock Up | 1d | 2020-07-08 | 2020-07-08 |  |
| 10 | 3.7 | Hall C Lock Up | 1d | 2020-07-08 | 2020-07-08 |  |
| 11 | 3.8 | Hall D Lock Up | 1d | 2020-07-08 | 2020-07-08 |  |
| 12 | 4 | **Cryo** | 6d | 2020-06-28 | 2020-07-03 |  |
| 13 | 4.1 | 4.5k Reroute for Repair | 2d | 2020-06-28 | 2020-06-29 |  |
| 14 | 4.2 | Pull 4.5k Return Bypass U Tube | 1d | 2020-06-30 | 2020-06-30 |  |
| 15 | 4.3 | INJ/NL Pumpdown Start | 1d | 2020-07-01 | 2020-07-01 |  |
| 16 | 4.4 | SL/LERF Pumpdown | 1d | 2020-07-02 | 2020-07-02 |  |
| 17 | 4.5 | Pumpdown/Filling Complete | 1d | 2020-07-03 | 2020-07-03 |  |
| 18 | 5 | **SSG** | 9d | 2020-06-30 | 2020-07-08 |  |
| 19 | 5.1 | SA Camera Fix | 1d | 2020-06-30 | 2020-06-30 |  |
| 20 | 5.2 | Sweep Changes | 1d | 2020-07-01 | 2020-07-01 |  |
| 21 | 5.3 | MBSY1C Troubleshooting | 1d | 2020-07-08 | 2020-07-08 |  |
| 22 | 6 | **EES IC** | 2d | 2020-06-30 | 2020-07-01 |  |
| 23 | 6.1 | Standard HCO | 2d | 2020-06-30 | 2020-07-01 |  |
| 24 | 7 | **EES RF** | 6d | 2020-06-30 | 2020-07-05 |  |
| 25 | 7.1 | Repairs and HCO | 2d | 2020-06-30 | 2020-07-01 |  |
| 26 | 7.2 | INJ/NL Recovery | 2d | 2020-07-02 | 2020-07-03 |  |
| 27 | 7.3 | Separator Recovery | 1d | 2020-07-03 | 2020-07-03 |  |
| 28 | 7.4 | SL Recovery | 2d | 2020-07-03 | 2020-07-04 |  |
| 29 | 7.5 | Energy Push | 2d | 2020-07-04 | 2020-07-05 |  |

Notes:
- 15: Start filling INJ/C100 Modules First Reinstall 4.5k U Tube
- 16: Finish filling INJ/NL Start filling C100's
- 17: Pumpdown and Filling Complete

| ID | WBS | Task | Duration | Start | Finish | Predecessors |
| --- | --- | --- | --- | --- | --- | --- |
| 30 | 8 | **Installation** | 2d | 2020-06-30 | 2020-07-01 |  |
| 31 | 8.1 | Tunnel Walkthrough | 1d | 2020-06-30 | 2020-06-30 |  |
| 32 | 8.2 | HCO | 1d | 2020-07-01 | 2020-07-01 |  |
| 33 | 9 | **EES DC** | 9d | 2020-06-30 | 2020-07-08 |  |
| 34 | 9.1 | Inspections and INJ Trims | 1d | 2020-06-30 | 2020-06-30 |  |
| 35 | 9.2 | Main Machine Trims | 3d | 2020-07-01 | 2020-07-03 |  |
| 36 | 9.3 | ARC Box Supply Restore | 2d | 2020-07-03 | 2020-07-04 |  |
| 37 | 9.4 | Hall Power Supplies | 1d | 2020-07-08 | 2020-07-08 |  |
| 38 | 10 | **SRF** | 1d | 2020-07-02 | 2020-07-02 |  |
| 39 | 10.1 | 1L25 FE Measurements | 1d | 2020-07-02 | 2020-07-02 |  |
| 40 | 11 | **Facilities** | 2d | 2020-06-30 | 2020-07-01 |  |
| 41 | 11.1 | Belt/Filter Repairs | 2d | 2020-06-30 | 2020-07-01 |  |
| 42 | 12 | **Gun** | 2d | 2020-06-30 | 2020-07-01 |  |
| 43 | 12.1 | Reactivate Cathode | 2d | 2020-06-30 | 2020-07-01 |  |
| 44 | 12.2 | Cathode Rotatation (PQB) | 1d | 2020-07-01 | 2020-07-01 |  |
| 45 | 13 | **Beam Ops** | 12d | 2020-07-02 | 2020-07-13 |  |
| 46 | 13.1 | Warm RF INJ | 1d | 2020-07-02 | 2020-07-02 | 43 |
| 47 | 13.2 | INJ Restore | 2d | 2020-07-03 | 2020-07-04 | 46 |
| 48 | 13.3 | PQB Verification | 1d | 2020-07-03 | 2020-07-03 |  |
| 49 | 13.4 | Beam to 3R | 1d | 2020-07-05 | 2020-07-05 | 47, 48 |
| 50 | 13.5 | Arc1 M5,6 | 1d | 2020-07-06 | 2020-07-06 | 49 |
| 51 | 13.6 | Rematch to 2R | 1d | 2020-07-07 | 2020-07-07 | 50 |
| 52 | 13.7 | Beam to 4R | 1d | 2020-07-08 | 2020-07-08 | 51 |
| 53 | 13.8 | Beam to 6R | 1d | 2020-07-09 | 2020-07-09 | 52 |
| 54 | 13.9 | Assess 5R BComm Setting | 1d | 2020-07-09 | 2020-07-09 | 52 |
| 55 | 13.10 | Beam to 8R | 1d | 2020-07-10 | 2020-07-10 | 53, 54 |
| 56 | 13.11 | Beam to 5C | 1d | 2020-07-11 | 2020-07-11 | 55 |
| 57 | 13.12 | Tuning to Halls | 2d | 2020-07-12 | 2020-07-13 |  |
| 58 | 14 | 6 Weeks Physics | 42d | 2020-07-14 | 2020-08-24 | 2 |

Notes:
- 31: Checking and fixing water leaks
- 44: After heat and reactivation of cathode. PQB folks and CIS will need some time to realign the cathode rotation.
